# LRAUVBuildScheduleRev.A_Backup

How a schedule from MS Project changed from version to version. A marks actual dates.

## Version 1 (saved 2018-01-09, file LRAUVBuildScheduleRev.A_Backup.mpp)

| ID | WBS | Task | Duration | Start | Finish | Predecessors | Complete | Total float | Constraint |
| --- | --- | --- | --- | --- | --- | --- | --- | --- | --- |
| 1 | 1 | **A-200467-17_PressHull_BUILD_5** | 134d | 2017-09-27 A | 2018-04-02 |  | 38% | 97d |  |
| 2 |  | Receive P-200626_AlumPressHull_EndDome_FWD_Rev.G | 1d | 2017-09-27 A | 2017-09-27 A |  | 100% |  |  |
| 3 |  | Receive fwd bulkhead connectors | 10d | 2017-09-27 A | 2017-10-10 A |  | 100% |  |  |
| 4 |  | FWD dome wiring | 5d | 2017-10-11 A | 2018-01-15 | 3, 2 |  | 124.5d |  |
| 5 |  | Assemble A-200579-14_InternalChassis_V3 | 10d | 2017-11-15 A | 2018-01-25 | 4 | 25% | 124.5d |  |
| 6 |  | Receive P-200466-08_EndDome_AFT_Rev.C | 1d | 2017-09-27 A | 2017-09-27 A |  | 100% |  | start no earlier than 2017-09-27 |
| 7 |  | Receive aft bulkhead connectors | 10d | 2017-09-27 A | 2017-10-10 A |  | 100% |  |  |
| 8 |  | AFT dome wiring | 5d | 2017-10-11 A | 2018-01-15 | 7, 6 |  | 132d |  |
| 9 | 1.8 | **A-201330-12_VB-Sys_V2** | 82d | 2017-09-27 A | 2018-01-18 |  | 65% | 129d |  |
| 10 |  | A-200620-08_VB-Resrvoir | 2.5d | 2017-09-27 A | 2018-01-10 |  | 50% | 135.75d | start no earlier than 2017-09-27 |
| 11 |  | P-201775-16 Valve Panel Mount Bracket fabrication | 16d | 2017-10-31 A | 2018-01-18 |  | 70% | 129d | finish no earlier than 2017-11-21 |
| 12 |  | A-200991-11_ValveAssem final assembly | 2.5d | 2017-09-27 A | 2018-01-18 | 11FF | 50% | 129d | start no earlier than 2017-09-27 |
| 13 | 1.9 | **A-201541-13_SecBattAssem_V3.3** | 95d | 2017-09-27 A | 2018-02-06 |  | 43% | 116d | start no earlier than 2017-09-27 |
| 14 |  | Assemble half-pak battery modules | 5d | 2017-09-27 A | 2017-11-16 A |  | 100% |  | start no earlier than 2017-09-27 |
| 15 |  | Test half-pak battery modules | 20d | 2017-11-17 A | 2018-01-15 | 14 | 75% | 116d | start no earlier than 2017-11-17 |
| 16 |  | Degauss half-pak battery modules | 6d | 2018-01-16 | 2018-01-23 | 15 |  | 116d | start no earlier than 2018-01-08 |
| 17 |  | Assemble complete battery module | 5d | 2018-01-24 | 2018-01-30 | 16 |  | 116d | start no earlier than 2018-01-08 |
| 18 |  | A-201907-17_FlagAssem_V2 | 5d | 2018-01-31 | 2018-02-06 | 17 |  | 116d | start no earlier than 2018-01-08 |
| 19 |  | A-201567-14_Complete Drive Assembly_V4 | 5d | 2018-01-31 | 2018-02-06 | 17 |  | 116d | start no earlier than 2018-01-08 |
| 20 | 1.10 | **A-201882-17_RF chassis_V2** | 47d | 2017-11-10 A | 2018-01-15 |  | 88% | 132d | start no earlier than 2017-11-10 |
| 21 |  | Replace RF MUX PCB component | 30d | 2017-11-10 A | 2017-12-21 A |  | 100% |  | start no earlier than 2017-11-10 |
| 22 |  | 3 way mux assembly complete | 5d | 2017-12-22 A | 2017-12-28 A | 21 | 100% |  | start no earlier than 2017-12-22 |
| 23 |  | Test 3 way mux assembly | 5d | 2018-01-09 | 2018-01-15 | 22 |  | 132d | start no earlier than 2018-01-08 |
| 24 | 1.11 | **A-201904-17_LoadContAssem_V2** | 114d | 2017-09-27 A | 2018-03-05 |  | 33% | 97d |  |
| 25 |  | Receive and configure load control boards | 2.5d | 2017-09-27 A | 2017-11-14 A |  | 100% |  |  |
| 26 |  | Receive all mechanical parts | 10d | 2017-09-27 A | 2018-01-09 |  | 95% | 136.5d |  |
| 27 |  | Load control backplane complete | 20d | 2017-11-10 A | 2018-01-15 |  | 75% | 105d | start no earlier than 2017-11-10 |
| 28 |  | Analog load control board complete | 35d | 2017-11-10 A | 2018-02-14 |  | 25% | 110.75d | start no earlier than 2017-11-10 |
| 29 |  | Complete high voltage converter PCB assembly | 40d | 2018-01-09 | 2018-03-05 |  |  | 97d | start no earlier than 2018-01-08 |
| 30 |  | A-201908-17_Stbd & Port_EZSV_Assem_Rev.A | 2d | 2017-11-03 A | 2018-01-10 |  |  | 135d | start no earlier than 2017-09-27 |
| 31 |  | A-200508-08_MotorAssem | 2d | 2017-09-27 A | 2017-11-13 A |  | 100% |  | start no earlier than 2017-09-27 |
| 32 |  | A-200503-08_ThrusterMotorAssy_V3 | 10d | 2018-01-08 | 2018-01-19 | 31 |  | 128d | start no earlier than 2018-01-08 |
| 33 |  | Receive & Fabricate Qty 4 A-Launch_Cart_Frame | 3.75d | 2017-10-26 A | 2017-12-14 A |  | 100% |  | start no earlier than 2017-09-27 |
| 34 |  | Assemble internal chassis components for harness fit | 5d | 2018-01-16 | 2018-01-22 | 27 |  | 105d | start no earlier than 2017-12-08 |
| 35 |  | Test fit first article wire harness's | 2d | 2018-01-23 | 2018-01-24 | 34 |  | 105d | start no earlier than 2017-12-15 |
| 36 |  | Receive final wire harness's | 20d | 2018-01-25 | 2018-02-21 | 35 |  | 105d | start no earlier than 2017-12-19 |
| 37 |  | Final assembly of all internal pressure hull components | 20d | 2018-03-06 | 2018-04-02 | 33, 32, 26, 19, 18, 12, 10, 8, 5, 25, 30, 36, 28, 29, 23 |  | 97d | start no earlier than 2018-01-16 |
| 38 |  | Paint aluminum pressure hulls | 30d | 2018-01-09 | 2018-02-19 |  |  | 117d | start no earlier than 2018-01-08 |
| 39 |  | All A-200467-17_PressHull_components complete | 0d | 2018-02-13 A | 2018-02-13 A | 37 | 100% |  |  |
| 40 | 2 | **A-200502-08_TailControlAssem_V7** | 161d | 2017-09-27 A | 2018-05-09 |  | 27% | 0d | start no earlier than 2017-09-27 |
| 41 |  | A-200618-08_Fin_Assem_V6, receive fin axles | 29d | 2017-09-27 A | 2018-01-18 |  | 75% | 79.75d | start no earlier than 2017-09-27 |
| 42 |  | A-200618-08_Fin_Assem_V6, receive final molded fins | 20d | 2018-01-09 | 2018-02-05 | 41FF |  | 67d | start no earlier than 2018-01-08 |
| 43 |  | A-200711-09_CS_LDA_Acuator wiring and assembly | 30d | 2017-11-10 A | 2018-01-29 |  | 50% | 72d | start no earlier than 2017-11-10 |
| 44 |  | A-200731-09_ElvCrnk/A-200732-09_RuddrCrnk 1st article insp. | 0d | 2018-01-08 | 2018-01-08 |  |  | 77d | start no earlier than 2018-01-08 |
| 45 |  | A-200731-09_ElvCrnk/A-200732-09_RuddrCrnk fabrication | 10d | 2018-01-09 | 2018-01-22 | 44 |  | 77d | start no earlier than 2018-01-08 |
| 46 |  | Bond A-200751-09_HATCH_TailShellAssem, fabricate hatch | 1d | 2018-01-09 | 2018-01-09 |  |  | 86d | start no earlier than 2018-01-08 |
| 47 |  | A-200751-09_TailShellAssem, fabricate shell | 60d | 2018-01-09 | 2018-04-02 | 46FF |  | 27d | start no earlier than 2018-01-08 |
| 48 |  | A-200924-10_ExtBladderAssem | 10d | 2018-01-09 | 2018-01-22 |  |  | 77d | start no earlier than 2018-01-08 |
| 49 |  | A-201176-17_CompAssem_V2 | 5d | 2017-10-10 A | 2017-11-29 A |  | 100% |  | start no earlier than 2017-09-27 |
| 50 |  | A-201500-17_DW_HrdWrAssem Fabrication | 20d | 2018-01-09 | 2018-02-05 |  |  | 67d | start no earlier than 2018-01-08 |
| 51 |  | Receive A-201916-17_TailFoamAssy_V6 | 30d | 2017-10-20 A | 2018-01-29 |  | 50% | 0d | must start on 2017-10-20 |
| 52 | 2.12 | **A-201798-16_Antenna Rev.I** | 161d | 2017-09-27 A | 2018-05-09 |  | 28% | 0d |  |
| 53 |  | Design new antenna base | 7.5d | 2017-09-27 A | 2018-01-18 |  |  | 59.5d |  |
| 54 |  | Fabricate new antenna base | 20d | 2018-01-18 | 2018-02-15 | 53 |  | 59.5d | start no earlier than 2018-01-08 |
| 55 |  | Deliver Antenna drawings with wire length to Jose | 1d | 2017-11-10 A | 2017-11-10 A |  | 100% |  | start no earlier than 2017-11-10 |
| 56 |  | Solder in coax to Antenna PCB | 3d | 2018-01-09 | 2018-01-11 | 55 |  | 84d | start no earlier than 2018-01-08 |
| 57 |  | Receive parts for antenna and MUX PCB's | 25d | 2017-11-10 A | 2017-12-14 A |  | 100% |  | start no earlier than 2017-11-10 |
| 58 |  | Complete test molding | 10d | 2017-12-19 A | 2018-01-02 A | 54, 57, 56 | 100% |  | start no earlier than 2017-12-19 |
| 59 |  | Mold antennas | 15d | 2018-01-09 | 2018-01-29 | 58 |  | 64d | start no earlier than 2018-01-08 |
| 60 |  | Order and receive coax antenna wet cable | 10d | 2017-12-18 A | 2017-12-29 A |  | 100% |  | start no earlier than 2017-12-17 |
| 61 |  | Over mold antenna coax with Poly U | 30d | 2018-01-01 A | 2018-02-09 | 60 | 20% | 0d |  |
| 62 |  | Terminate antenna wet cable with SMA conn | 20d | 2018-02-12 | 2018-03-09 | 61 |  | 0d |  |
| 63 |  | Terminate antenna wet cable with DGO conn | 35d | 2018-03-12 | 2018-04-27 | 62 |  | 0d |  |
| 64 |  | Cast antenna base sealing connectors | 8d | 2018-04-30 | 2018-05-09 | 63, 59 |  | 0d |  |
| 65 |  | A-200502-08_TailControlAssemComplete | 0d | 2018-05-09 | 2018-05-09 | 51, 52, 50, 49, 48, 47, 45, 43, 42, 64 |  | 0d | start no earlier than 2018-02-02 |
| 66 | 3 | **A-xxxxxx-xx_PayLoad-ShortNose (Kemp)** | 231d | 2017-09-27 A | 2018-08-15 |  |  | 0d |  |
| 67 |  | Specify shortnose payload design | 2.5d | 2017-09-27 A | 2018-01-11 |  |  | 49.5d |  |
| 68 |  | Design housing for shortnose AHRS | 0d | 2017-09-27 A | 2017-10-10 A |  | 100% |  |  |
| 69 |  | Fabricate AHRS housing | 20d | 2018-01-11 | 2018-02-08 | 68, 67 |  | 59.5d | start no earlier than 2018-01-08 |
| 70 |  | Fabricate or locate all shortnose parts | 30d | 2018-01-11 | 2018-02-22 | 67 |  | 49.5d | start no earlier than 2018-01-08 |

| ID | WBS | Task | Duration | Start | Finish | Predecessors | Complete | Total float | Constraint |
| --- | --- | --- | --- | --- | --- | --- | --- | --- | --- |
| 71 |  | Assemble shortnose payload | 5d | 2018-02-22 | 2018-03-01 | 70, 69 |  | 49.5d | start no earlier than 2018-01-08 |
| 72 |  | A-xxxxxx-xx_PayLoad-ShortNoseComplete | 0d | 2018-03-01 | 2018-03-01 | 71 |  | 49.5d | start no earlier than 2018-01-08 |
| 73 | 3.7 | **AUV #4 (Kemp) Final Integration and test** | 70d | 2018-05-10 | 2018-08-15 |  |  | 0d | start no earlier than 2018-02-13 |
| 74 |  | AUV #4 (Kemp) Final assembly of all components | 20d | 2018-05-10 | 2018-06-06 | 72, 65, 39 |  | 0d | start no earlier than 2018-02-13 |
| 75 |  | AUV #4 (Kemp) Lab systems integration and test | 40d | 2018-06-07 | 2018-08-01 | 74 |  | 0d | start no earlier than 2018-03-13 |
| 76 |  | AUV #4 (Kemp) Sea Trials | 10d | 2018-08-02 | 2018-08-15 | 75, 38 |  | 0d | start no earlier than 2018-05-08 |
| 77 |  | AUV #4 (Kemp) Complete | 0d | 2018-08-15 | 2018-08-15 | 76 |  | 0d | start no earlier than 2018-05-22 |
| 78 | 4 | **AUV 5,6,7 science payload Systems** | 171d | 2017-09-27 A | 2018-05-23 |  | 2% | 60d |  |
| 79 |  | Specify AUV 5,6,7 science payload design | 7.5d | 2017-09-27 A | 2018-01-12 |  | 50% | 63.25d |  |
| 80 |  | Complete design drawings for science payload | 20d | 2018-01-12 | 2018-02-09 | 79 |  | 63.25d | start no earlier than 2018-01-08 |
| 81 |  | Design review science payload design | 0d | 2018-02-09 | 2018-02-09 | 80 |  | 63.25d | start no earlier than 2018-01-08 |
| 82 |  | Fabricate and paint nose shell | 40d | 2018-02-09 | 2018-04-06 | 38FF, 81 |  | 93.25d | start no earlier than 2018-01-08 |
| 83 |  | Fabricate all nose cone hardware | 30d | 2018-02-09 | 2018-03-23 | 81 |  | 73.25d | start no earlier than 2018-01-08 |
| 84 |  | Order and receive nose cone wet cabling | 40d | 2018-02-09 | 2018-04-06 | 81 |  | 63.25d | start no earlier than 2018-01-08 |
| 85 |  | Assemble science payload AUV 5, 6 & 7 | 20d | 2018-04-06 | 2018-05-04 | 84, 83 |  | 63.25d | start no earlier than 2018-02-07 |
| 86 |  | Final assembly LRAUV #5, 6 & 7 | 10d | 2018-05-10 | 2018-05-23 | 39, 65, 85 |  | 60d | start no earlier than 2018-03-07 |

## Version 2 (saved 2018-02-24, file LRAUVBuildScheduleRev.A.mpp)

Last finish 2018-08-15 → 2018-07-05 (-41d). Complete tasks 17 → 37.

Added:

| ID | Task | Duration | Start | Finish | Predecessors | Constraint | Resources |
| --- | --- | --- | --- | --- | --- | --- | --- |
| 31 | A-200567-08_PropShaftAssem | 10d | 2018-01-08 A | 2018-03-02 |  | start no earlier than 2018-01-08 | Mike Parker |
| 44 | Test CS_LDA Acuator assembly | 5d | 2018-03-02 | 2018-03-08 | 43 |  | Ben |
| 47 | Weld WHOI A-200731-09_ElvCrnk/A-200732-09 | 2d | 2018-02-23 | 2018-02-26 |  | start no earlier than 2018-02-23 | Mike Parker [25%] |
| 49 | A-200751-09_TailShellAssem, fabricate shell unit #2 | 33d | 2018-02-26 | 2018-04-11 |  | start no earlier than 2018-02-23 | Pleskunas Design LLC |
| 52 | Oil fill and leak test CompAssem_V2 | 5d | 2017-11-30 A | 2018-03-01 | 51 |  | Jim Scholfield |
| 76 | Complete first two deck boxes | 10d | 2018-02-23 | 2018-03-08 |  | start no earlier than 2018-02-23 | Paul Coenen [25%] |

Removed: 11 P-201775-16 Valve Panel Mount Bracket fabrication; 46 Bond A-200751-09_HATCH_TailShellAssem, fabricate hatch; 54 Fabricate new antenna base

Changed:

| ID | Task | Start | Finish | Duration | Complete | Total float | Predecessors | Other |
| --- | --- | --- | --- | --- | --- | --- | --- | --- |
| 1 | **A-200467-17_PressHull_BUILD_5** |  | 2018-04-02 → 2018-04-19 (+17d) | 134d → 146.5d | 38% → 78% | 97d → 55.25d |  |  |
| 4 | FWD dome wiring |  | 2018-01-15 A |  | 0% → 100% | 124.5d → none |  |  |
| 5 | Assemble A-200579-14_InternalChassis_V3 |  | 2018-01-25 → 2018-03-07 (+41d) |  |  | 124.5d → 35.5d |  |  |
| 8 | AFT dome wiring |  | 2018-01-15 A |  | 0% → 100% | 132d → none |  |  |
| 9 | **A-201330-12_VB-Sys_V2** |  | 2018-01-18 → 2018-01-10 A (-8d) | 82d → 75.25d | 65% → 100% | 129d → none |  |  |
| 10 | A-200620-08_VB-Resrvoir |  | 2018-01-10 A |  | 50% → 100% | 135.75d → none |  |  |
| 11 | A-200991-11_ValveAssem final assembly |  | 2018-01-18 → 2017-10-03 A (-107d) |  | 50% → 100% | 129d → none | P-201775-16 Valve Panel Mount Bracket fabricationFF → none |  |
| 12 | **A-201541-13_SecBattAssem_V3.3** |  | 2018-02-06 → 2018-03-22 (+44d) | 95d → 126.5d | 43% → 68% | 116d → 2.5d |  |  |
| 14 | Test half-pak battery modules |  | 2018-01-15 → 2018-03-01 (+45d) |  | 75% → 80% | 116d → 28.25d |  |  |
| 15 | Degauss half-pak battery modules | 2018-01-16 A | 2018-01-23 → 2018-03-08 (+44d) |  | 0% → 25% | 116d → 28.25d |  | resources none → Denis Klimov |
| 16 | Assemble complete battery module | 2018-01-24 → 2018-03-08 A (+43d) | 2018-01-30 → 2018-03-15 (+44d) |  | 0% → 75% | 116d → 24.5d |  | constraint start no earlier than 2018-01-08 → start no earlier than 2018-02-23 |
| 17 | A-201907-17_FlagAssem_V2 | 2018-01-31 → 2018-03-15 (+43d) | 2018-02-06 → 2018-03-22 (+44d) |  |  | 116d → 24.5d |  | constraint start no earlier than 2018-01-08 → start no earlier than 2018-02-23 |
| 18 | A-201567-14_Complete Drive Assembly_V4 | 2018-01-31 A | 2018-02-06 A |  | 0% → 100% | 116d → none |  |  |
| 19 | **A-201882-17_RF chassis_V2** |  | 2018-01-15 → 2018-01-18 A (+3d) | 47d → 49.25d | 88% → 100% | 132d → none |  |  |
| 21 | 3 way mux assembly complete |  | 2017-12-28 A → 2018-01-11 A (+14d) |  |  |  |  |  |
| 22 | Test 3 way mux assembly | 2018-01-09 → 2018-01-11 A (+2d) | 2018-01-15 → 2018-01-18 A (+3d) |  | 0% → 100% | 132d → none |  | constraint start no earlier than 2018-01-08 → start no earlier than 2018-01-05 |
| 23 | **A-201904-17_LoadContAssem_V2** |  | 2018-03-05 → 2018-03-15 (+10d) | 114d → 122d | 33% → 74% | 97d → 79.75d |  |  |
| 25 | Receive all mechanical parts |  | 2018-01-09 A |  | 95% → 100% | 136.5d → none |  |  |
| 26 | Load control backplane complete |  | 2018-01-15 → 2018-03-02 (+46d) |  |  | 105d → 108d |  |  |
| 27 | Analog load control board complete |  | 2018-02-14 → 2018-03-08 (+22d) |  | 25% → 75% | 110.75d → 34.25d |  |  |
| 28 | Complete high voltage converter PCB assembly | 2018-01-09 → 2018-01-01 A (-8d) | 2018-03-05 → 2018-03-15 (+10d) |  | 0% → 65% | 97d → 29d |  | constraint start no earlier than 2018-01-08 → start no earlier than 2018-01-01 |
| 29 | A-201908-17_Stbd & Port_EZSV_Assem_Rev.A |  | 2018-01-10 A |  | 0% → 100% | 135d → none |  |  |
| 32 | A-200503-08_ThrusterMotorAssy_V3 | 2018-01-08 A | 2018-01-19 → 2018-02-28 (+40d) |  | 0% → 75% | 128d → 40.5d |  |  |
| 34 | Assemble internal chassis components for harness fit | 2018-01-16 A | 2018-01-22 A |  | 0% → 100% | 105d → none |  |  |
| 35 | Test fit first article wire harness's | 2018-01-23 A | 2018-01-24 → 2018-02-26 (+33d) |  | 0% → 95% | 105d → 112.9d |  |  |
| 36 | Receive final wire harness's | 2018-01-25 A | 2018-02-21 A |  | 0% → 100% | 105d → none |  |  |
| 37 | Final assembly of all internal pressure hull components | 2018-03-06 → 2018-03-22 (+16d) | 2018-04-02 → 2018-04-19 (+17d) |  |  | 97d → 24.5d |  |  |
| 38 | Paint aluminum pressure hulls | 2018-01-09 → 2018-01-05 A (-4d) | 2018-02-19 → 2018-02-15 A (-4d) |  | 0% → 100% | 117d → none |  | constraint start no earlier than 2018-01-08 → start no earlier than 2018-01-05 |
| 39 | All A-200467-17_PressHull_components complete | 2018-02-13 A → 2018-04-19 (+65d) | 2018-02-13 A → 2018-04-19 (+65d) |  | 100% → 0% | none → 24.5d |  |  |
| 40 | **A-200502-08_TailControlAssem_V7** |  | 2018-05-09 → 2018-05-23 (+14d) | 161d → 171d | 27% → 65% | 0d → 30.75d |  |  |
| 41 | A-200618-08_Fin_Assem_V6, fab. & weld fin axles |  | 2018-01-18 → 2018-03-05 (+46d) |  | 75% → 80% | 79.75d → 107.2d |  | was named A-200618-08_Fin_Assem_V6, receive fin axles |
| 42 | A-200618-08_Fin_Assem_V6, receive final molded fins | 2018-01-09 → 2018-01-05 A (-4d) | 2018-02-05 → 2018-02-01 A (-4d) |  | 0% → 100% | 67d → none |  | constraint start no earlier than 2018-01-08 → start no earlier than 2018-01-05 |
| 43 | A-200711-09_CS_LDA_Acuator wiring and assembly |  | 2018-01-29 → 2018-03-01 (+31d) |  | 50% → 87% | 72d → 54d |  |  |
| 45 | A-200731-09_ElvCrnk/A-200732-09_RuddrCrnk 1st article insp. | 2018-01-08 → 2018-01-04 A (-4d) | 2018-01-08 → 2018-01-04 A (-4d) |  | 0% → 100% | 77d → none |  | constraint start no earlier than 2018-01-08 → finish no earlier than 2018-01-04 |
| 46 | A-200731-09_ElvCrnk/A-200732-09_RuddrCrnk fabrication | 2018-01-09 A | 2018-01-22 A |  | 0% → 100% | 77d → none |  |  |
| 48 | A-200751-09_TailShellAssem, fabricate shell unit #1 | 2018-01-09 → 2018-01-08 A (-1d) | 2018-04-02 → 2018-02-21 A (-40d) | 60d → 33d | 0% → 100% | 27d → none | Bond A-200751-09_HATCH_TailShellAssem, fabricate hatchFF → none | was named A-200751-09_TailShellAssem, fabricate shell; constraint start no earlier than 2018-01-08 → finish no earlier than 2018-02-21; resources Water Rat → Pleskunas Design LLC |
| 50 | A-200924-10_ExtBladderAssem | 2018-01-09 A | 2018-01-22 A |  | 0% → 100% | 77d → none |  | resources Jim Scholfield → Jim Scholfield; Mike Parker |
| 53 | A-201500-17_DW_HrdWrAssem Fabrication | 2018-01-09 → 2018-02-26 (+48d) | 2018-02-05 → 2018-03-23 (+46d) |  |  | 67d → 43d |  | constraint start no earlier than 2018-01-08 → start no earlier than 2018-02-23 |
| 54 | Receive A-201916-17_TailFoamAssy_V6 |  | 2018-01-29 → 2018-01-30 A (+1d) |  | 50% → 100% | 0d → none |  | constraint must start on 2017-10-20 → none |
| 55 | **A-201798-16_Antenna Rev.I** |  | 2018-05-09 → 2018-05-23 (+14d) | 161d → 171d | 28% → 60% | 0d → 18d |  |  |
| 56 | Design new antenna base |  | 2018-01-18 → 2018-01-02 A (-16d) | 7.5d → 1d | 0% → 100% | 59.5d → none |  |  |
| 58 | Solder in coax to Antenna PCB | 2018-01-09 → 2018-01-08 A (-1d) | 2018-01-11 → 2018-01-10 A (-1d) |  | 0% → 100% | 84d → none |  |  |
| 60 | Complete test molding |  | 2018-01-02 A → 2018-01-10 A (+8d) | 10d → 6d |  |  | Fabricate new antenna base, 59, 58 → 59, 58FF, 56 | constraint start no earlier than 2017-12-19 → none |
| 61 | Mold antennas | 2018-01-09 → 2018-01-11 A (+2d) | 2018-01-29 → 2018-02-07 A (+9d) | 15d → 20d | 0% → 100% | 64d → none |  |  |
| 63 | Over mold antenna coax with Poly U |  | 2018-02-09 A |  | 20% → 100% | 0d → none |  |  |
| 64 | Terminate antenna wet cable with SMA conn | 2018-02-12 → 2018-02-26 (+14d) | 2018-03-09 → 2018-03-23 (+14d) |  |  | 0d → 20.75d |  | constraint none → start no earlier than 2018-02-23 |
| 65 | Terminate antenna wet cable with DGO conn | 2018-03-12 → 2018-03-26 (+14d) | 2018-04-27 → 2018-05-11 (+14d) |  |  | 0d → 20.75d |  |  |
| 66 | Cast antenna base sealing connectors | 2018-04-30 → 2018-05-14 (+14d) | 2018-05-09 → 2018-05-23 (+14d) |  |  | 0d → 20.75d |  |  |
| 67 | A-200502-08_TailControlAssemComplete | 2018-05-09 → 2018-04-11 (-28d) | 2018-05-09 → 2018-04-11 (-28d) |  |  | 0d → 10.75d | 54, 55, 53, 51, 50, 48, 46, 43, 42, 66 → 54, 53, 51, 50, 48, 46, 42, 31, 49, 44, 52, 47 |  |
| 68 | **A-xxxxxx-xx_PayLoad-ShortNose (Kemp)** |  | 2018-08-15 → 2018-07-02 (-44d) | 231d → 199d |  |  |  |  |
| 69 | Specify shortnose payload design |  | 2018-01-11 → 2018-02-28 (+48d) |  |  | 49.5d → 25.5d |  |  |
| 71 | Fabricate AHRS housing | 2018-01-11 → 2018-02-28 (+48d) | 2018-02-08 → 2018-03-28 (+48d) |  |  | 59.5d → 35.5d |  |  |
| 72 | Fabricate or locate all shortnose parts | 2018-01-11 → 2018-02-28 (+48d) | 2018-02-22 → 2018-04-11 (+48d) |  |  | 49.5d → 25.5d |  |  |
| 73 | Assemble shortnose payload | 2018-02-22 → 2018-04-11 (+48d) | 2018-03-01 → 2018-04-18 (+48d) |  |  | 49.5d → 25.5d |  |  |
| 74 | A-xxxxxx-xx_PayLoad-ShortNoseComplete | 2018-03-01 → 2018-04-18 (+48d) | 2018-03-01 → 2018-04-18 (+48d) |  |  | 49.5d → 25.5d |  |  |
| 75 | **AUV #4 (Kemp) Final Integration and test** | 2018-05-10 → 2018-02-23 (-76d) | 2018-08-15 → 2018-07-02 (-44d) | 70d → 92d |  |  |  |  |
| 77 | AUV #4 (Kemp) Final assembly of all components in chassis | 2018-05-10 → 2018-03-15 (-56d) | 2018-06-06 → 2018-04-19 (-48d) | 20d → 25d |  | 0d → 2.5d | 74, 67, 39 → 74FF, 67FF, 39FF | was named AUV #4 (Kemp) Final assembly of all components; constraint start no earlier than 2018-02-13 → start no earlier than 2018-03-13 |
| 78 | AUV #4 (Kemp) Lab systems integration and test | 2018-06-07 → 2018-04-19 (-49d) | 2018-08-01 → 2018-06-14 (-48d) |  |  | 0d → 2.5d | 77 → 77, 76, 66FF |  |
| 79 | AUV #4 (Kemp) Sea Trials | 2018-08-02 → 2018-06-14 (-49d) | 2018-08-15 → 2018-06-28 (-48d) |  |  | 0d → 2.5d |  |  |
| 80 | AUV #4 (Kemp) Complete | 2018-08-15 → 2018-07-02 (-44d) | 2018-08-15 → 2018-07-02 (-44d) |  |  |  |  | constraint start no earlier than 2018-05-22 → must finish on 2018-07-02 |
| 81 | **AUV 5,6,7 science payload Systems** |  | 2018-05-23 → 2018-07-05 (+43d) | 171d → 201.75d |  | 60d → 0d |  |  |
| 82 | Specify AUV 5,6,7 science payload design |  | 2018-01-12 → 2018-03-01 (+48d) |  |  | 63.25d → 0d |  |  |
| 83 | Complete design drawings for science payload | 2018-01-12 → 2018-03-01 (+48d) | 2018-02-09 → 2018-03-29 (+48d) |  |  | 63.25d → 0d |  |  |
| 84 | Design review science payload design | 2018-02-09 → 2018-03-29 (+48d) | 2018-02-09 → 2018-03-29 (+48d) |  |  | 63.25d → 0d |  |  |
| 85 | Fabricate and paint nose shell | 2018-02-09 → 2018-03-29 (+48d) | 2018-04-06 → 2018-05-24 (+48d) |  |  | 93.25d → 49.25d |  |  |
| 86 | Fabricate all nose cone hardware | 2018-02-09 → 2018-03-29 (+48d) | 2018-03-23 → 2018-05-10 (+48d) |  |  | 73.25d → 29.25d |  |  |
| 87 | Order and receive nose cone wet cabling | 2018-02-09 → 2018-03-29 (+48d) | 2018-04-06 → 2018-05-24 (+48d) |  |  | 63.25d → 0d |  |  |
| 88 | Assemble science payload AUV 5, 6 & 7 | 2018-04-06 → 2018-05-24 (+48d) | 2018-05-04 → 2018-06-21 (+48d) |  |  | 63.25d → 0d |  |  |
| 89 | Final assembly LRAUV #5, 6 & 7 | 2018-05-10 → 2018-06-21 (+42d) | 2018-05-23 → 2018-07-05 (+43d) |  |  | 60d → 0d |  |  |
